# 3GPP_Release-2000

Schedule from MS Project, 2000-01-01 to 2012-09-17, A marks actual dates.

## Calendars

- Standard: Mon-Fri 08:00-12:00, 13:00-17:00; Sat-Sun off. Exceptions (off unless hours are given): 2000-01-15 08:00-12:00, 13:00-17:00, 2009-05-30 08:00-12:00, 13:00-17:00.

## Resources

| Resource |
| --- |
| NP |
| N1 |
| N2 |
| N3 |
| N4 |
| N5 |
| TP |
| T1 |
| T2 |
| T3 |
| RP |
| R1 |
| R2 |
| R3 |
| R4 |
| SP |
| S1 |
| S2 |
| S3 |
| S4 |
| S5 |
| PCG |
| GP |
| No |
| CN4 |
| ? |
| WG G2 |
| G2 |
| G1 |
| G4 |
| G3 |
| All |
| Generic |
| MLST |
| G5 |
| S3, G2 |
| WG T2 |
| GP,G1 |
| G4,G5 |
| OMA |
| GP-G2 |
| Yes |
| GP, |
| N4, |
| GP, N1 |
| CT5 |
| C5 |
| C1 |
| C4 |
| C3 |
| C6 |
| G1, |
| 4 |
| ct |
| c,s,r |
| CT,RAN,SA |
| G2, |
| G1, G3 |
| CT6 |
| CT1 |
| CT1, CT3, CT4 |
| C1, C3, C4 |
| CP |
| R5 |
| C |
| Rel-8 |
| GP, G2 |
| R1,R4 |
| S5,C1 |
| CT,RAN,SA,GERAN |
| S3,C1,C4 |
| 5 |
| S1,C1,C3,C4,S5 |
| S1,C1,C3,C5 |
| S1,C1,C3,C4 |
| S1,S5 |
| S2,S3 |
| RAN,SA |
| RP,S5 |
| S2,CT |
| S1,CT |
| S1,CT,GERAN |
| S1,C5 |
| S3,CT |
| S4,CT |
| C1,SA |
| S1,S2 |
| S1,S4 |
| S2,S2,S3,CT |
| S2,S3,CT |
| S1,CT,GX |
| S1,S4,CT |
| S2,S2,S3,S5,CT |
| S1,S2,CT |
| S1,S2,S3,CT |
| S1,S2,S3,S5CT |
| S1,S2,S3,S5,CT |
| S2,S5,CT |
| S4,S3 |
| S1,C1 |
| CP,C1 |
| C1,C3 |
| C1,C3,C4 |
| S1,S5,CT |
| C4,C3 |
| CP,RAN,SA,GERAN |
| S1,S2,S3,S5,CP |
| S2,S3,CP |
| S2,CP |
| S1,CP,GX |
| S1,CP |
| S1,S4,CP |
| S1,S2,CP |
| S1,S2,S3,CP |
| S2,S5,CP |
| S3,CP |
| S1,S5,CP |
| RAN,SA,GERAN |
| S1,S2,S3,S5,C1,C3,C4,C6 |
| S2,S3,C1,C3,C4 |
| S2,C4 |
| S2,C1,C3,C4 |
| S2,C1,C4 |
| S2,S3,C1,C4 |
| S1,C1,C4,G2 |
| C1,C4 |
| S1,C1,C3 |
| S1,S4,C1,C3,C4 |
| S1,S2,S3,C1,C3,C4 |
| S2,S5,C3 |
| S1,S2,C1,C4 |
| S2,C1 |
| S2,C1,C3 |
| S3,C1,C3,C4 |
| S1,S5,C1,C3,C4 |
| S2,C3,C4 |
| C3,C1 |
| R2,R4 |
| R2,R5 |
| RP,R5 |
| RP,S5,R5 |
| R1,R5 |
| S1,C1,R5 |
| S1,C1,S4,R5 |
| GERAN |
| G3new |
| G1, G3new |
| C4,C1,C3 |
| R1.R4 |
| R1, R4 |
| R2,R3 |
| C3,C4 |
| S4,C3 |
| S4,C3,C1,C4 |
| S1,S2,C1 |
| S1,S2<C1,C3,C4 |
| S1,S2,C1,C3,C4 |
| S5,C1,C3,C4 |
| GP,C4 |
| C4,C1 |
| S2,S1 |
| RP,SP,GP |
| RP,SP,CP,GP |
| CP,GP,RP,SP |
| GP,C4,S4 |
| S1,C1,C4 |
| S1,S2,C3,C1 |
| R2,R4,R3 |
| CP,GP, RP,SP |
| S2,S1,C1,S5 |
| S2,S1,C1 |
| S1,C1,S4 |
| S1,S2,GP,C4,R2 |
| S1,GP,R2 |
| S1,C6 |
| S1,S2,C1,S4 |
| S2,S3,S5,C1,C3,C4 |
| S2,S5,C1 |
| S2,S3,S5 |
| CP,GP, RP,SP,TP |
| S2,C4,C1 |
| S1,C1,C4,S3 |
| S2,S5 |
| S3,C1 |
| S3,C4 |
| S1,C4 |
| S2,S5,C3,C1 |
| S2,S1,S5,C1,C4 |
| S1,R1,C3 |
| S1,C1,R2 |
| S2,S1,C1,C4 |
| S1,C1,C6 |
| GP,S4,C4,C1,C3 |
| C3,C1,C4 |
| S1,C4,C1 |
| S1,S3 |
| S1,S2,S5,C3,C4 |
| R4,G1 |
| G1,R4 |
| RP,GP |
| R4,GP |
| R3,R2 |
| C6,RP,SP |
| R5,C6 |
| CP,RP,SP |
| RP,SP,CP |
| R3,S5 |
| S1,S2,RP |
| S1,S2,S5,RP |
| S2,S1,RP |
| Rel-9 |
| S3,C6 |
| S1,S2,S3,S5,RP |
| S2,S1,S3 |
| S1,S2,S3 |
| S1,S2,S3,S5 |
| C6,R5 |
| S1,S2,RP,GP |
| S1,S2,S4,S5,RP,GP |
| GP,G2 |
| GP,GP, N1 |
| GP,S2,G1,G2 |
| GP,R2,R3,S2,G1,G2 |
| GP,S2,S5,R2,R3,G2,G1 |
| GP,R3 |
| N4,S2 |
| GP,RP |
| GP,S2,RP |
| G5,G4 |
| G4,R3 |
| S2,R2,R4 |
| S1,S2,R2,R4 |
| GP,S5 |
| S1,S2,S5 |
| R4,R5 |
| R4,R2,R3,R5 |
| S2,S5,N4,RP |
| S1,S2,S3,S5,NP |
| S2,S4,S5 |
| T2,S1,S4,S5 |
| SP,RP |
| S2,RP |
| S1,S2,CP,G2 |
| CP,SP |
| S1,G2 |
| SP,CP |
| S1,S2,S5,C3 |
| S1,C1,S3 |
| G1,G3new |
| C4, C3, C1C4 |
| C4,C3,C1 |
| S1,S2,S3,S5,R2,R3,R4 |
| S1,S2,S3,R2 |
| S2,S3,S5,C4,R2 |
| S1,S5,C1 |
| S1,S2,S3,C1,C3,C4,R2 |
| Ggp |
| S3,S2,C1,C4,G2 G3new |
| R1,R2,R3,R4 |
| R4,R1,R2,R3 |
| R4,R2,R3 |
| S1,C1,C4,R2 |
| R4,R2 |
| S2,C4,R2,R4 |
| S2,C4,R2 |
| S2,S3,S5,C3,C4,R2 |
| S1,S2,S4,T2 |
| S1,S2,S4 |
| S1,S2,S4,R5 |
| S3,S2,C1,C4,G2,G3new |
| GP,C1 |
| S1,S5,C4 |
| S1,S2,S3,S5,R2,R3,R4,GP |
| GP,C4,C3,C1 |
| SMG9 |
| SMG1 |
| SMG2 |
| N3,R5 |
| N1, N2, N4, G1, G2, R3, S1, SMG2 |
| S1,SMG1 |
| SMG1,N4 |
| N1,C1,N4,S1,T2,G2,SMG1,SMG2,SMG3,SMG7,SMG9 |
| SMG1,N2 |
| S1,S2,N2,N4 |
| N4,N2 |
| G1,G2 |
| G1,G2,C1 |
| G1,G2,N1 |
| SMG2, SMG1, SMG3, SMG4, SMG7, SMG9, SMG10, G1, G2, G3, N1, N3, T2 |
| SMG2,G1 |
| S1,G1,G2 |
| SMG1,N1,G1,G2 |
| G2,G1 |
| G1,G2,G3,S1,S2,SMG1,SMG2,SMG7,N1,N2,N3,N4,T2 |
| 23.003, 23.008, 29.060 |
| S1, S2, SMG1, SMG2, SMG12, G2, N1, N2, N4 |
| S1,S2,SMG1,SMG2,SMG12,G2,N1,N2,N4 |
| S1,SMG2,N1,N2,N4 |
| SMG1,T2 |
| S1,N1,N2,N4 |
| S1,S2,N5 |
| SMG2,SMG7,G2,T2 |
| S3,N1,N2,N3 |
| S3,N1,N2,N4 |
| SMG9,T3 |
| SMG2,SMG3,SMG7,G2,N2 |
| SMG2,N1,G1,G2 |
| S1,N2 |
| N1,N3 |
| S2,N1 |
| N1,N2,N4 |
| N2,N1,N4 |
| N2,N4 |
| S1,T3 |
| T2,N3 |
| S3,N2 |
| T2,S1 |
| S1,N4 |
| SMG1,SMG2,SMG7 |
| N1,S1,T1 |
| SMG1,SMG3 |
| N4,S2,N1 |
| S1,S2,SMG1,SMG2,SMG7,G1,G2,G3,N1,N2,N3,N4,T2 |
| SMG1,N3 |
| S1,N3 |
| CP,SP,SMG |
| CP,SP,TP,GP,SMG |
| NP,SP,TP,GP,SMG |
| NP,GP, RP,SP,TP |
| SMG2,SMG1,SMG3,SMG4,SMG7,SMG9,SMG10,G1,G2,G3,N1,N3,T2 |
| S1,N2,N4 |
| S1,S2,S3,C1,C3,C4,R2,R3 |
| R2,R3,R1,R4 |
| R2,R3,R4 |
| R2,R1,R3,R4 |
| S2,C4,R2,R3,R4 |
| S2,C4,R2,R1,R3,R4 |
| S2,S3,S5,C3,C4,R2,R3,R4 |
| R1,R2,R4 |
| R3,R1,R4 |
| S2, |
| S2,G2, |
| S1,S2,G2, |
| S1,S2,G2,R2,R3, |
| S1,S2,C4,G2,R2,R3 |
| S1,S2,N4,G2,R2,R3 |
| S1,S2,SMG1,SMG2,SMG12,G2,N1,N2,N4,R2,R3 |
| S1,SMG1,T2 |
| S1,SMG1,S2 |
| S1,N4,N2 |
| T2,N1,N3 |
| S3,N2,N4 |
| SMG1,SMG2,SMG3,SMG7,SMG9,N1,C1,N4,S1,T2,G2 |
| SMG1,N2,N4 |
| S2,T2,N1,N2,N4 |
| S1,T2 |
| S1,S2,C4 |
| S1,S2,N4,RP |
| S2,N4 |
| S1,S2,N3,N4,RP |
| S1,S2,SMG1,SMG2,SMG12,T2,G2,N1,N2,N4,R2,R3 |
| S1,T2,N1,N3 |
| S1,S2,SMG1,SMG2,SMG12,T2,G2,N1,N2,N3,N4,R2,R3 |
| S1,S2,S3,SMG1,SMG2,SMG12,G2,N1,N2,N4,R2,R3 |
| S1,S2,SMG,G1,G2,G3,N1,N2,N3,N4,T2 |
| S1,S2,SMG,T2,G2,N1,N2,N3,N4,R2,R3 |
| S1,S3,SMG,G1,G2,G3,N1,N2,N3,N4,T2 |
| S1,S3,T2,N2,N4 |
| S1,S2,SMG,T2,G1,G2,G3,N1,N2,N3,N4 |
| G2,S2 |
| T1,R5 |
| R5,T1 |
| S1,S2,S4,T1,R5 |
| S1,S2,S4,S5,T1,RP,GP |
| S1,S2,S3,S5,R2,R3,R4,GP,C1 |
| S1,S2,S3,SMG1,SMG2,SMG12,N1,N2,N4,R2,R3 |
| S1,S2,SMG,T2,N1,N2,N3,N4,R2,R3 |
| NP,SP,TP,SMG |
| S1,S2,SMG,T2,N1,N2,N3,N4 |
| SMG,N1 |
| SMG |
| S1,S2,SMG1,SMG2,SMG7,N1,N2,N3,N4,T2 |
| SMG2,SMG1,SMG3,SMG4,SMG7,SMG9,SMG10,N1,N3,T2 |
| S1,SMG |
| SMG2,SMG7,T2 |
| SMG2,S2 |
| N1,N2,N4,R3,S1,SMG |
| SMG2,SMG3,SMG7,N2 |
| SMG1,SMG2,SMG3,SMG7,SMG9,N1,C1,N4,S1,T2 |
| S1,S2,SMG,N3,N4,RP |
| S1,S2,S4,SMG,N3,N4,RP |
| S2,C1,C4,R2,R1,R3,R4 |
| R2,S2,S4 |
| G3new,R5 |
| GP,R4 |
| S2,S4,R2 |
| SP,GP |
| RP,SP |
| S2,S1,S3,S5 |
| S3,S1 |
| N4,N1,N2,S2 |
| RP,SP,S1 |
| CP,GP,RP,SP,S1 |

## Schedule

| ID | WBS | Task | Type | Duration | Start | Finish | Complete | Remaining | Baseline start | Baseline finish | Baseline duration | Total slack | Constraint | Resources | Work | Actual work | Text6 | Text1 | Text2 | Text4 | Text5 | Text7 | Text8 | Text9 | Text12 |
| --- | --- | --- | --- | --- | --- | --- | --- | --- | --- | --- | --- | --- | --- | --- | --- | --- | --- | --- | --- | --- | --- | --- | --- | --- | --- |
| 1 | 1 | Version 2009 Oct 15 |  | 3318d? | 2000-01-03 | 2012-09-17 |  |  | 2000-01-03 | 2012-09-17 | 3318d? | 0d | start no earlier than 2000-01-03 | S1 | 26544h |  |  |  |  |  |  |  |  |  |  |
| 2 | 2 | SA3 Rel-9 Stage 2 exceptions to 12/2009 |  | 1d? | 2000-01-03 | 2000-01-03 |  |  | 2000-01-03 | 2000-01-03 | 1d? | 3317d |  |  |  |  |  |  |  |  |  |  |  |  |  |
| 3 | 3 | "CTRL + a" to display all the 3GPP fields |  | 1d | 2000-01-03 | 2000-01-03 |  |  | 2000-01-03 | 2000-01-03 | 1d | 3317d |  | S1 | 8h |  |  |  |  |  |  |  |  |  |  |
| 5 | 4 | Gantt: dark blue=done; light blue=to be done; grey: previous values; black=summary |  | 1d? | 2000-01-03 | 2000-01-03 |  |  | 2000-01-03 | 2000-01-03 | 1d? | 3317d | start no earlier than 2000-01-01 | S1 | 8h |  |  |  |  |  |  |  |  |  |  |
| 7 | 5 | Release 10 Features | milestone | 0d? | 2000-01-01 | 2000-01-01 |  |  | 2000-01-01 | 2000-01-01 | 0d? | 3318d |  | RP,SP,S1 |  |  | Rel-10 |  |  |  |  |  |  |  |  |
| 8 | 6 | **Enhanced Home NodeB / eNodeB continuation of Rel-9** |  | 395d? | 2008-12-11 A | 2010-06-15 | 35% | 256.75d? | 2008-12-11 | 2010-06-15 | 395d? | 589d |  | S2 | 6312h | 2209.2h | Rel-10 | eEHNB | PCG-23 | Alcatel-Lucent | Nicolas Drevon | SP-44 | Maurice |  |  |
| 9 | 6.1 | IMS aspects of Architecture for Home NodeB |  | 394d? | 2008-12-11 A | 2010-06-15 | 35% | 256.1d? | 2008-12-11 | 2010-06-15 | 394d? | 589d | finish no earlier than 2010-06-15 | S2 | 3152h | 1103.2h | Rel-10 | EHNB-IMS | PCG-22 | Alcatel-Lucent | Nicolas Drevon | SP-42 | Maurice |  |  |
| 10 | 7 | H(e)NB enhancements |  | 126d? | 2009-09-24 | 2010-03-18 |  |  | 2009-09-24 | 2010-03-18 | 126d? | 652d | finish no earlier than 2010-03-18 | S1 | 1008h |  | Rel-10 | EHNBF | PCG-23 | NEC | joerg.swetina@nw.neclab.eu | SP-45 | Alain |  |  |
| 11 | 8 | **Registration in Densely-populated area (RED)** |  | 665d? | 2007-03-12 A | 2009-09-24 A | 100% |  | 2007-03-12 | 2009-09-24 | 665d? |  |  | S1 | 9544h | 9544h | Rel-10 | RED |  | NTT DoCoMo | tanakai@nttdocomo.co.jp | SP-35 | Alain |  |  |
| 12 | 8.1 | Stage 1 for RED |  | 4d? | 2007-03-12 A | 2007-03-15 A | 100% |  | 2007-03-12 | 2007-03-15 | 4d? |  | start no earlier than 2007-03-12 | S1 | 32h | 32h | Rel-10 | RED |  | NTT DoCoMo | takakurat@s1.nttdocomo.co.jp | SP-35 | Alain |  |  |
| 13 | 8.2 | Deleted - Stage 2 for RED |  | 524d? | 2007-09-25 A | 2009-09-24 A | 100% |  | 2007-09-25 | 2009-09-24 | 524d? |  | finish no earlier than 2009-09-24 | S2 | 4192h | 4192h | Rel-10 | RED |  | NTT DoCoMo | tanakai@nttdocomo.co.jp | SP-37 | Maurice | PCG-23 | SP-45 |
| 14 | 9 | **Network Improvements for Machine-Type Communications** |  | 452d? | 2008-09-18 A | 2010-06-10 | 38% | 280.1d? | 2008-09-18 | 2010-06-10 | 452d? | 592d |  | S1,S2 | 7680h | 2920.82h | Rel-10 | NIMTC | PCG-21 | KPN | Toon Norp (toon.norp AT tno.nl) | SP-41 | Alain |  |  |
| 15 | 9.1 | Stage 1 for NIMTC |  | 322d? | 2008-09-18 A | 2009-12-10 | 60% | 128.8d? | 2008-09-18 | 2009-12-10 | 322d? | 722d | finish no earlier than 2009-12-10 | S1 | 2576h | 1545.6h | Rel-10 | NIMTC | PCG-21 | KPN | Toon Norp (toon.norp AT tno.nl) | SP-41 | Alain |  |  |
| 16 | 9.2 | Stage 2 for NIMTC |  | 186d? | 2009-09-24 | 2010-06-10 |  |  | 2009-09-24 | 2010-06-10 | 186d? | 592d | finish no earlier than 2010-06-10 | S2 | 1488h |  | Rel-10 | NIMTC | PCG-23 | Samsung | Erik Guttman (erik.guttman@partner.samsung.com) | SP-45 | Maurice |  |  |
| 17 | 10 | **GTP-based S8 chaining** |  | 262d? | 2008-12-11 A | 2009-12-10 | 35% | 170.3d? | 2008-12-11 | 2009-12-10 | 262d? | 722d |  | S2 | 4192h | 1467.2h | Rel-10 | GTPchaining | PCG-22 | Huawei | Haining Wang (wanghaining@huawei.com) | SP-42 | Maurice |  |  |
| 18 | 10.1 | Stage 2 for GTPchaining |  | 262d? | 2008-12-11 A | 2009-12-10 | 35% | 170.3d? | 2008-12-11 | 2009-12-10 | 262d? | 722d | finish no earlier than 2009-12-10 | S2 | 2096h | 733.6h | Rel-10 | GTPchaining | PCG-22 | Huawei | Haining Wang (wanghaining@huawei.com) | SP-42 | Maurice |  |  |
| 19 | 11 | Multi Access PDN Connectivity |  | 263d? | 2009-03-13 A | 2010-03-15 | 75% | 65.75d? | 2009-03-13 | 2010-03-15 | 263d? | 655d | finish no earlier than 2010-03-15 | S2 | 2104h | 1578h | Rel-10 | MAPCON | PCG-22 | Telecom Italia | ivano.guardini@telecomitalia.it | SP-43 | Maurice |  |  |
| 20 | 12 | **IMS Service Continuity – Inter Device Transfer enhancements** |  | 266d? | 2009-06-04 A | 2010-06-10 | 38% | 164.89d? | 2009-06-04 | 2010-06-10 | 266d? | 592d |  | S1,S2 | 4704h | 1619.2h | Rel-10 | IMS_SC_eIDT | PCG-23 | Huawei | Amar Deol (adeol@huawei.com) | SP-44 | Alain |  |  |
| 21 | 12.1 | Stage 1 for IMS_SC_eIDT |  | 136d? | 2009-06-04 A | 2009-12-10 | 90% | 13.6d? | 2009-06-04 | 2009-12-10 | 136d? | 722d | start no earlier than 2009-06-04 | S1 | 1088h | 979.2h | Rel-10 | IMS_SC_eIDT | PCG-23 | Huawei | Amar Deol (adeol@huawei.com) | SP-44 | Alain |  |  |
| 22 | 12.2 | IMS Inter-UE Transfer enhancements (Stage 2) |  | 186d? | 2009-09-24 | 2010-06-10 |  |  | 2009-09-24 | 2010-06-10 | 186d? | 592d | finish no earlier than 2010-06-10 | S2 | 1488h |  | Rel-10 | IMS_SC_eIDT | PCG-23 | Huawei | HengLiang Zhang (hl_zhang@huawei.com) | SP-45 | Maurice |  |  |
| 23 | 13 | **IP-Short-Message-Gateway enhancements for CPM-SMS Interworking** |  | 186d? | 2009-09-24 A | 2010-06-10 | 19% | 151.44d? | 2009-09-24 | 2010-06-10 | 186d? | 592d |  | S1,S2 | 3416.8h | 358.4h | Rel-10 | CPM-SMS | PCG-23 | China Mobile | Qing Huang | SP-45 | Alain |  |  |
| 24 | 13.1 | Stage 1 for CPM-SMS |  | 56d? | 2009-09-24 A | 2009-12-10 | 80% | 11.2d? | 2009-09-24 | 2009-12-10 | 56d? | 722d | finish no earlier than 2009-12-10 | S1 | 448h | 358.4h | Rel-10 | CPM-SMS | PCG-23 | China Mobile | Qing Huang | SP-45 | Alain |  |  |
| 25 | 13.2 | Stage 2 for CPM-SMS |  | 185.1d? | 2009-09-24 | 2010-06-10 |  |  | 2009-09-24 | 2010-06-10 | 185.1d? | 592d | finish no earlier than 2010-06-10 | S2 | 1480.8h |  | Rel-10 | CPM-SMS | PCG-23 | Orange | Antoine Mouquet | SP-45 | Maurice |  |  |
| 26 | 14 | **Completion of Communications on Not Logged-in** |  | 1d? | 2009-09-24 A | 2009-09-24 A | 100% |  | 2009-09-24 | 2009-09-24 | 1d? |  |  | S1 | 16h | 16h | Rel-10 | CCNL | PCG-23 | Deutsche Telekom | Kurt Bischinger | SP-45 | Alain |  |  |
| 27 | 14.1 | Stage 1 for CCNL |  | 1d? | 2009-09-24 A | 2009-09-24 A | 100% |  | 2009-09-24 | 2009-09-24 | 1d? |  | start no earlier than 2009-09-24 | S1 | 8h | 8h | Rel-10 | CCNL | PCG-23 | Deutsche Telekom | Kurt Bischinger | SP-45 | Alain |  |  |

Notes:
- 1: -
- 2: -
- 3: -
- 5: -
- 7: -
- 8: SP#44 Umbrella Feature created to host WIs moved out of Rel-9
- 9: SP#45 completion 12/09=>06/10. SP#44 Moved from Rel-9 to Rel-10 / Text3: 23.832, 23.232
- 10: Items beyond Rel-9 UID_400035 Enhanced Home NodeB / eNodeB (EHNB) / Text3: 22.220
- 11: SP#35 Stage 1 completed. SP#40 SA2 moved to Rel-9. SP#43 moved to Rel-10. SP#45 Stage 2 work stopped/abandoned. / Text3: WID identifies also impacted CT1 24.008, RAN2 25.331
- 12: SP#35 completed. / Text3: 22.101 CR#0207
- 13: SP#45 Stage 2 work stopped/abandoned. SP#40 SA2 moved to Rel-9. SP#43 moved to Rel-10. / Text3: draft TR 23.880 withdrawn, 23.002, 23.060, 23.221, 23.236
- 14: SP#45 updated WID SP-080649=>SP-090658 (added Stage 2). TS 22.368v100 for Information. Stage 1 completion 09/09=>12/09. Triggered by Rel-8 UID_7027 Study on Facilitating Machine to Machine Communication in GSM and UMTS (FS_M2M) TR 22.868
- 15: SP#45 TS 22.368v100 for Information. Stage 1 completion 09/09=>12/09 / Text3: 22.368
- 16: SP#45 updated WID SP-080649=>SP-090658 (added SA2 part) / Text3: 23.888 (Architectural Enhancements for machine-type communications)
- 17: Stage 1 in UID_320022 Rel-8 Requirements for evolution of the 3GPP system architecture (AIPN-SAE): 22.278, 22.011, 22.246
- 18: - / Text3: 23.402 (Chaining GTP-S8 based architecture and procedures)
- 19: SP#45 WID updated SP-090100=>SP-090659. Completion 12/09=>03/10. Triggered by TR 23.861 UID_410043 FS_MAPIM. Stage 1 in Rel-9 22.278 (6.2 - IP session control) / Text3: 23.401, 23.402, 23.237
- 20: Rel-9 set Inter-Device Transfer requirements UID_410033 (IMS_SCC-IDT). Add additional scenarios and requirements for IDT.
- 21: - / Text3: 22.228
- 22: - / Text3: 23.237, 23.292, new TR 23.8ab (IMS Inter-UE transfer enhancements)
- 23: IP-SM-GW enhancements for interworking with OMA CPM. External requirements (Stage 1 in OMA-RD-CPM-V1_0-20090310-C)
- 24: External requirements (Stage 1 in OMA-RD-CPM-V1_0-20090310-C) / Text3: 22.340 (IMS messaging)
- 25: - / Text3: 23.204 (Support of SMS over generic 3GPP IP access), new TR 23.824 (IP-SM-GW enhancements for interworking with OMA CPM)
- 26: SP#45 WID approved. Stage 1 completed
- 27: SP#45 WID approved. Stage 1 completed / Text3: 22.173 CR#0056r1 Call Completion on Not Logged in (CCNL)

| ID | WBS | Task | Type | Duration | Start | Finish | Complete | Remaining | Baseline start | Baseline finish | Baseline duration | Total slack | Constraint | Resources | Work | Actual work | Text1 | Text2 | Text4 | Text6 | Text7 | Text8 | Text11 | Text9 | Text12 |
| --- | --- | --- | --- | --- | --- | --- | --- | --- | --- | --- | --- | --- | --- | --- | --- | --- | --- | --- | --- | --- | --- | --- | --- | --- | --- |
| 28 | 15 | **Local IP Access and Selected Internet IP Traffic Offload** |  | 256d? | 2009-09-24 A | 2010-09-16 | 3% | 247.81d? | 2009-09-24 | 2010-09-16 | 256d? | 522d |  | S2,S1,S3,S5 | 9608h | 242h | LIPA_SIPTO | PCG-23 | Huawei, China Mobile | Rel-10 | SP-45 | Maurice |  |  |  |
| 29 | 15.1 | TR on LIPA_SIPTO |  | 121d? | 2009-09-24 | 2010-03-11 |  |  | 2009-09-24 | 2010-03-11 | 121d? | 657d | finish no earlier than 2010-03-11 | S2 | 968h |  | LIPA_SIPTO | PCG-23 | Huawei, China Mobile | Rel-10 | SP-45 | Maurice |  |  |  |
| 30 | 15.2 | Stage 1 for LIPA_SIPTO |  | 121d? | 2009-09-24 A | 2010-03-11 | 25% | 90.75d? | 2009-09-24 | 2010-03-11 | 121d? | 657d | finish no earlier than 2010-03-11 | S1 | 968h | 242h | LIPA_SIPTO | PCG-23 | Huawei, China Mobile | Rel-10 | SP-45 | Alain |  |  |  |
| 31 | 15.3 | Stage 2 for LIPA_SIPTO |  | 191d? | 2009-09-24 | 2010-06-17 |  |  | 2009-09-24 | 2010-06-17 | 191d? | 587d | finish no earlier than 2010-06-17 | S2 | 1528h |  | LIPA_SIPTO | PCG-23 | Huawei, China Mobile | Rel-10 | SP-45 | Maurice |  |  |  |
| 32 | 15.4 | Security for LIPA_SIPTO |  | 256d? | 2009-09-24 | 2010-09-16 |  |  | 2009-09-24 | 2010-09-16 | 256d? | 522d | finish no earlier than 2010-09-16 | S3 | 2048h |  | LIPA_SIPTO | PCG-23 | Huawei, Qualcomm Europe | Rel-10 | SP-45 | Dionisio |  |  |  |
| 33 | 15.5 | OAM&P for LIPA_SIPTO |  | 256d? | 2009-09-24 | 2010-09-16 |  |  | 2009-09-24 | 2010-09-16 | 256d? | 522d | finish no earlier than 2010-09-16 | S5 | 2048h |  | LIPA_SIPTO | PCG-23 | nn | Rel-10 | SP-45 | Dionisio |  |  |  |
| 34 | 16 | **IP Flow Mobility and seamless WLAN offload** |  | 186d? | 2009-09-24 A | 2010-06-10 |  | 185.85d? | 2009-09-24 | 2010-06-10 | 186d? | 592d |  | S2,S1 | 3960h | 3.2h | IFOM | PCG-23 | Qualcomm Europe | Rel-10 | SP-45 | Maurice |  |  |  |
| 35 | 16.1 | Stage 1 for IFOM |  | 123d? | 2009-09-24 A | 2010-03-15 |  | 122.75d? | 2009-09-24 | 2010-03-15 | 123d? | 655d | finish no earlier than 2010-03-15 | S1 | 984h | 2h | IFOM | PCG-23 | Qualcomm Europe | Rel-10 | SP-45 | Alain |  |  |  |
| 36 | 16.2 | Stage 2 for IFOM |  | 186d? | 2009-09-24 | 2010-06-10 |  |  | 2009-09-24 | 2010-06-10 | 186d? | 592d | finish no earlier than 2010-06-10 | S2 | 1488h |  | IFOM | PCG-23 | Qualcomm Europe | Rel-10 | SP-45 | Maurice |  |  |  |
| 37 | 17 | **Enabling Coder Selection and Rate Adaptation for UTRAN and E-UTRAN for Load Adaptive Applications** |  | 186d? | 2009-09-24 | 2010-06-10 |  |  | 2009-09-24 | 2010-06-10 | 186d? | 592d |  | S2 | 4464h |  | ECSRA_LAA | PCG-23 | Qualcomm Europe | Rel-10 | SP-45 | Maurice |  |  |  |
| 38 | 17.1 | TR on ECSRA_LAA |  | 186d? | 2009-09-24 | 2010-06-10 |  |  | 2009-09-24 | 2010-06-10 | 186d? | 592d | finish no earlier than 2010-06-10 | S2 | 1488h |  | ECSRA_LAA | PCG-23 | Qualcomm Europe | Rel-10 | SP-45 | Maurice |  |  |  |
| 39 | 17.2 | Stage 2 for ECSRA_LAA |  | 186d? | 2009-09-24 | 2010-06-10 |  |  | 2009-09-24 | 2010-06-10 | 186d? | 592d | finish no earlier than 2010-06-10 | S2 | 1488h |  | ECSRA_LAA | PCG-23 | Qualcomm Europe | Rel-10 | SP-45 | Maurice |  |  |  |
| 40 | 18 | EEA3 and EIA3 (new Encryption & Integrity EPS security algorithms) |  | 266d? | 2009-06-04 | 2010-06-10 |  |  | 2009-06-04 | 2010-06-10 | 266d? | 592d | finish no earlier than 2010-06-10 | S3 | 2128h |  | EEA3_EIA3 | PCG-23 | CATR | Rel-10 | SP-44 | Dionisio |  |  |  |
| 41 | 19 | 1.28 Mcps TDD Repeater |  | 659d? | 2007-12-04 A | 2010-06-11 | 50% | 329.5d? | 2007-12-04 | 2010-06-11 | 659d? | 591d | finish no earlier than 2010-06-11 | R4 | 5272h | 2636h | RANimp-Repeaters1.28TDD | PCG-21 | RITT | Rel-10 | RP-38 | Stefania | RP-090691 |  |  |
| 42 | 20 | 1.28 Mcps TDD Multi-carrier HSUPA |  | 316d? | 2009-09-18 | 2010-12-03 |  |  | 2009-09-18 | 2010-12-03 | 316d? | 466d | finish no earlier than 2010-12-03 | R1,R2,R3,R4 | 2528h |  | TDD_MC_HSUPA | PCG-23 | CATR | Rel-10 | RP-45 | Patrick |  |  |  |
| 43 | 21 | A-GNSS Minimum Performance for UTRAN |  | 261d? | 2009-09-18 | 2010-09-17 |  |  | 2009-09-18 | 2010-09-17 | 261d? | 521d | finish no earlier than 2010-09-17 | R4 | 2088h |  | AGNSSPerf_UTRAN | PCG-23 | Thales | Rel-10 | RP-45 | Stefania |  |  |  |
| 44 | 22 | UE Over The Air (Antenna) conformance testing methodology - Laptop mounted equipment Free Space test |  | 521d? | 2009-09-18 | 2011-09-16 |  |  | 2009-09-18 | 2011-09-16 | 521d? | 261d | finish no earlier than 2011-09-16 | R4 | 4168h |  | UEAnt_FSTest | PCG-23 | CATR | Rel-10 | RP-45 | Stefania |  |  |  |
| 45 | 23 | (Small) Technical Enhancements and Improvements for Rel-10 |  | 136d? | 2009-06-04 | 2009-12-10 |  |  | 2009-06-04 | 2009-12-10 | 136d? | 722d | finish no earlier than 2009-12-10 | All | 1088h |  | TEI10 | PCG-23 | ALL | Rel-10 | SP-44 |  |  |  |  |
| 46 | 24 | **Deleted - Network Selection for non-3GPP Access** |  | 471d? | 2007-12-07 A | 2009-09-24 A | 100% |  | 2007-12-07 | 2009-09-24 | 471d? |  |  | S1,C6 | 10452.8h | 10452.8h | N3GtoNSP | PCG-21 | Telefonica O2 | Rel-10 | SP-38 | Alain |  | PCG-23 | SP-45 |
| 47 | 24.1 | Deleted - Stage 1 for N3GtoNSP |  | 471d? | 2007-12-07 A | 2009-09-24 A | 100% |  | 2007-12-07 | 2009-09-24 | 471d? |  | finish no earlier than 2009-12-10 | S1 | 3768h | 3768h | N3GtoNSP | PCG-21 | Telefonica O2 | Rel-10 | SP-38 | Alain |  | PCG-23 | SP-45 |
| 48 | 24.2 | Deleted - CT6 issues for N3GtoNSP |  | 471d? | 2007-12-07 A | 2009-09-24 A | 100% |  | 2007-12-07 | 2009-09-24 | 471d? |  | finish no earlier than 2009-12-04 | C6 | 3768h | 3768h | N3GtoNSP | PCG-21 | Telefonica O2 | Rel-10 | CP-38 | Xavier |  | PCG-23 | CP-45 |
| 49 | 25 | Release 10 Studies | milestone | 0d? | 2000-01-01 | 2000-01-01 |  |  | 2000-01-01 | 2000-01-01 | 0d? | 3318d | start no earlier than 2000-01-01 | RP,SP,S1 |  |  |  |  |  | Rel-10 |  |  |  |  |  |
| 50 | 26 | Study on Haptic Services |  | 262d? | 2009-03-12 A | 2010-03-11 | 50% | 131d? | 2009-03-12 | 2010-03-11 | 262d? | 657d | finish no earlier than 2010-03-11 | S1 | 2088h | 1040h | FS_Haptics | PCG-22 | SK Telecom | Rel-10 | SP-43 | Alain |  |  |  |
| 51 | 27 | Study on advanced requirements for IP interconnect |  | 528d? | 2007-12-04 A | 2009-12-10 | 80% | 105.6d? | 2007-12-04 | 2009-12-10 | 528d? | 722d | finish no earlier than 2009-12-10 | S1 | 4224h | 3379.2h | FS_IPXS | PCG-21 | Telefonica O2 | Rel-10 | SP-38 | Alain |  |  |  |
| 52 | 28 | Study on Unauthenticated PS Emergency Calls |  | 396d? | 2008-06-05 A | 2009-12-10 | 20% | 316.8d? | 2008-06-05 | 2009-12-10 | 396d? | 722d | finish no earlier than 2009-12-10 | S1 | 3168h | 633.6h | FS_UAPSEC | PCG-21 | Nokia Siemens Networks | Rel-10 | SP-40 | Alain |  |  |  |
| 53 | 29 | Study on Personal Broadcast Service |  | 322d? | 2008-09-18 A | 2009-12-10 | 90% | 32.2d? | 2008-09-18 | 2009-12-10 | 322d? | 722d | finish no earlier than 2009-12-10 | S1 | 2568h | 2310.4h | FS_PBS | PCG-21 | ETRI | Rel-10 | SP-41 | Alain |  |  |  |
| 54 | 30 | Study on LCS support in SAE for non-3GPP accesses |  | 322d? | 2008-09-18 A | 2009-12-10 | 70% | 96.3d? | 2008-09-18 | 2009-12-10 | 322d? | 722d | finish no earlier than 2009-12-10 | S1 | 2568h | 1797.6h | FS_LCS_n3GPP | PCG-21 | SK Telecom | Rel-10 | SP-41 | Alain |  |  |  |
| 55 | 31 | Study on System enhancements for the use of IMS services in Local BreakOut and Optimal Routing of Media |  | 575d? | 2007-10-01 A | 2009-12-10 | 80% | 115d? | 2007-10-01 | 2009-12-10 | 575d? | 722d | finish no earlier than 2009-12-10 | S2 | 4600h | 3680h | FS_IMS_LBO_ORM |  | Telecom Italia, BT | Rel-10 | SP-37 | Maurice |  |  |  |
| 56 | 32 | Study on Intra Domain Connection of RAN Nodes to Multiple CN Nodes |  | 525d? | 2008-03-12 A | 2010-03-15 | 30% | 367.5d? | 2008-03-12 | 2010-03-15 | 525d? | 655d | finish no earlier than 2010-03-15 | S2 | 4200h | 1260h | FS_IDC | PCG-21 | China Mobile | Rel-10 | SP-39 | Maurice |  |  |  |
| 57 | 33 | Study on IMS Evolution |  | 389d? | 2008-09-18 A | 2010-03-15 | 60% | 155.6d? | 2008-09-18 | 2010-03-15 | 389d? | 655d | finish no earlier than 2010-03-15 | S2 | 3112h | 1867.2h | FS_eIMS | PCG-21 | China Mobile | Rel-10 | SP-41 | Maurice |  |  |  |
| 58 | 34 | Study on enhancements to IMS border functions for IMS Interconnection of services |  | 455d? | 2008-09-18 A | 2010-06-15 | 20% | 364d? | 2008-09-18 | 2010-06-15 | 455d? | 589d | finish no earlier than 2010-06-15 | S2 | 3640h | 728h | FS_eIMS_IBCF | PCG-21 | Starent Networks | Rel-10 | SP-41 | Maurice |  |  |  |
| 59 | 35 | Study on Multi Access PDN connectivity and IP flow Mobility |  | 389d? | 2008-09-18 A | 2010-03-15 | 85% | 58.35d? | 2008-09-18 | 2010-03-15 | 389d? | 655d | finish no earlier than 2010-03-15 | S2,S1 | 3112h | 2645.2h | FS_MAPIM | PCG-21 | Qualcomm Europe | Rel-10 | SP-41 | Maurice |  |  |  |
| 60 | 36 | Study on Policy solutions and enhancements |  | 338d? | 2009-06-04 A | 2010-09-20 | 15% | 287.3d? | 2009-06-04 | 2010-09-20 | 338d? | 520d | finish no earlier than 2010-09-20 | S2,S1 | 2704h | 405.6h | FS_PP | PCG-23 | AT&T | Rel-10 | SP-44 | Maurice |  |  |  |
| 61 | 37 | Study on IPv6 Migration |  | 269d? | 2009-06-04 A | 2010-06-15 | 10% | 242.1d? | 2009-06-04 | 2010-06-15 | 269d? | 589d | finish no earlier than 2010-06-15 | S2 | 2152h | 215.2h | FS_IP6M | PCG-23 | China Mobile | Rel-10 | SP-44 | Maurice |  |  |  |
| 62 | 38 | Study on SR-VCC Enhancements |  | 338d? | 2009-06-04 A | 2010-09-20 | 6% | 317.4d? | 2009-06-04 | 2010-09-20 | 338d? | 520d | finish no earlier than 2010-09-20 | S2 | 2704h | 164.8h | FS_eSRVCC | PCG-23 | China Mobile | Rel-10 | SP-44 | Maurice |  |  |  |
| 63 | 39 | Study on Uplink Tx Diversity for HSPA |  | 218.4d? | 2009-08-18 | 2010-06-18 |  |  | 2009-08-18 | 2010-06-18 | 218.4d? | 586d | finish no earlier than 2010-06-18 | R4 | 1747.2h |  | FS_UL-TxDiv-HSPA | PCG-23 | Qualcomm Europe | Rel-10 | RP-45 | Stefania |  |  |  |
| 64 | 40 | Study on RAN improvements for Machine-Type Communications |  | 196d? | 2009-09-18 | 2010-06-18 |  |  | 2009-09-18 | 2010-06-18 | 196d? | 586d | finish no earlier than 2010-06-18 | R2,R1,R3,R4 | 1568h |  | FS_NIMTC-RAN | PCG-23 | Huawei | Rel-10 | RP-45 | Joern |  |  |  |
| 65 | 41 | Study on IMS based Peer-to-Peer Content Distribution Services |  | 196d? | 2009-09-24 | 2010-06-24 |  |  | 2009-09-24 | 2010-06-24 | 196d? | 582d | finish no earlier than 2010-06-24 | S1,S2 | 1568h |  | FS_IMS_PP-CDS | PCG-23 | China Mobile | Rel-10 | SP-45 | Alain |  |  |  |

Notes:
- 28: UID_400035 Enhanced Home NodeB/eNodeB (EHNB) has formerly covered Local IP Access to Internet and Local access to Home Network from the Home NodeB/eNodeB Features now covered by this WI. / Text5: patrice.hede@huawei.com, Tao Sun (suntao@chinamobile.com)
- 29: - / Text3: 23.829 (Local IP Access & Selected IP Traffic Offload) / Text5: patrice.hede@huawei.com, Tao Sun (suntao@chinamobile.com)
- 30: - / Text3: 22.101, 22.220 / Text5: Amar Deol (adeolf@huawei.com), Gang Li (ligangyf@chinamobile.com)
- 31: - / Text3: 23.060, 23.203, 23.401 / Text5: patrice.hede@huawei.com, Tao Sun (suntao@chinamobile.com)
- 32: - / Text3: 33.102, 33.107, 33.108, 33.320, 33.401 / Text5: Marcus Wong (mwong@huawei.com), Brian Rosenberg (bmr@qualcomm.com)
- 33: - / Text3: 32.101, 32.102, 32.405, 32.425, 32.452, 32.453, 32.581, 32.582, 32.583, 32.584, 32.591, 32.592, 32.593, 32.594, 32.64x, 32.76x / Text5: nn
- 34: Triggered by Rel-10 TR 23.861 (UID_410043 Study on Multi Access PDN connectivity and IP flow mobility - MAPIM). Charging aspects are to be considered for IP Flow Mobility and WLAN offloading. / Text5: Gerardo Giaretta (gerardo@qualcomm.com)
- 35: Service requirements for IP Flow Mobility partially in 22.278 and additional aspects in TR 23.861. 22.278 needs updating to capture aspects currently only in TR 23.861. / Text3: 22.278 / Text5: David Williams (dwilliam@qualcomm.com)
- 36: - / Text3: 23.203, 23.402, new TS 23.261 (IP Flow Mobility) / Text5: Gerardo Giaretta (gerardo@qualcomm.com)
- 37: Rel-10 Rate Adaptation. Triggered by Rel-9 RAN2 (UID_440013 Vocoder rate adaptation for LTE (LTEimp-Vocoder). Enhance existing (pre Rel-10) codec selection/rate adaptation based on network loading conditions and operator policies over UTRA/E-UTRA / Text5: AC Mahendran (ac@qualcomm.com)
- 38: Needs Liaison with SA4, RAN2 / Text3: new TR 23.abc (Enabling Encoder Selection and Rate Adaptation for UTRAN and E-UTRAN) / Text5: AC Mahendran (ac@qualcomm.com)
- 39: - / Text3: 23.060, 23.203, 23.228, 23.401 / Text5: AC Mahendran (ac@qualcomm.com)
- 40: develop new EPS algorithms acceptable to regions such as China / Text3: 35.xxx (EEA3 & EIA3 Algorithm Specification, Implementers’ test data, Design and evaluation report, Final project report), 33.401 (SAE Security Architecture) / Text5: Yuan Qi, yuanqi@mail.ritt.com.cn
- 41: RP#45 completion 12/09=>06/10 / Text3: 25.113, new 25.116, 25.153 (testing) / Text5: qinyan@chinattl.com
- 42: - / Text3: 25.102, 25.105, 25.123, 25.221, 25.222, 25.223, 25.224, 25.225, 25.306, 25.319, 25.321, 25.331, 25.423, 25.427, 25.433 / Text5: Aihui Song (songaihui@mail.ritt.com.cn)
- 43: Triggered by Rel-7 UID_20050 (GNSS in UTRAN) and Rel-8 UID_400051 (Support for Additional NSS). Linked to GERAN Rel-8 UID_38002 (A-GNSS Performances and Testing Procedures) / Text3: 25.171, 34.108, 34.123, 34.171, 34.109 / Text5: Michel.monnerat@thalesaleniaspace.com
- 44: - / Text3: 25.144, 25.914, 34.114 / Text5: Guo Lin (guolin@emcite.com)
- 45: -
- 46: SP#45 work stopped/abandoned / Text5: chris.friel@O2.com
- 47: SP#45 work stopped/abandoned / Text3: 22.011 / Text5: chris.friel@O2.com
- 48: SP#45 work stopped/abandoned / Text3: 22.234, 21.111, 31.101, 31.102, 31.103 / Text5: chris.friel@O2.com
- 49: -
- 50: SP#45 updated WID SP-090222=>SP-090664 (IMS extension, removed Mobile to also cover Fixed/Cordless/etc terminal). Haptic (human-machine tactile communication) extend service offering & richness of user experience beyond current visual & auditory senses / Text3: 22.987 / Text5: Jinhan Song
- 51: SP#45 TR 22.893 for Information. Linked to Rel-8 Feature UID_380060 IP Interconnection of Services (IPinterc) / Text3: 22.893 / Text5: chris.friel@O2.com
- 52: SP#44/45 stagnating at 20% / Text3: 22.984 / Text5: Juergen Merkel
- 53: SP#45 TR 22.947 for Information / Text3: 22.947 / Text5: Jaihyung Cho
- 54: SP#44 TR 22.913 for Information / Text3: 22.913 / Text5: Donghee Shim
- 55: SP#43 TR 23.894 for Information (Common and IP-CAN aspects). Linked to Study on Multimedia Session Continuity UID_350051, Study on Centralized IMS Service Control UID_330012, IMS inter-operator service interconnection interface UID_360011 / Text3: 23.894 / Text5: mario.madella@telecomitalia.it, victor.kueh@bt.com
- 56: SP#45 TR 23.823 for Information. Completion 12/09=>03/10. Linked to 23.236 / Text3: 23.823 / Text5: LIU HONG (liuhongyfw@chinamobile.com)
- 57: - / Text3: 23.812 / Text5: Li Gang (ligangyf@chinamobile.com), Yu Qing (yuqing@chinamobile.com)
- 58: SP#45 completion 12/09=>06/10 / Text3: 23.848 / Text5: Rajat Ghai (rghai@starentnetworks.com)
- 59: SP#45 completion 09/09=>03/10 (SA1 completed). Spin-off UID_430035 MAPCON and UID_450041 IFOM / Text3: 23.861 / Text5: Gerardo Giaretta (gerardog@qualcomm.com)
- 60: SP#45 completion 12/09=>09/10. Study an evolved policy solution through enhancement of 3GPP policy framework (Stage 2). Consider aspects such as DPI, traffic steering, enhancing service policies. / Text3: 23.813 / Text5: farooq.bari@att.com
- 61: Study how to migrate from IPv4 to IPv6-only with the help of transition mechanisms defined in IETF, and how to handle scenarios where not all services are provided via IPv6. Some of these solutions may have impacts on 3GPP network elements and terminals. / Text3: 23.975 / Text5: Li Lianyuan (lilianyuan@chinamobile.com), Liu Hong (liuhongyfw@chinamobile.com)
- 62: SP#45 completion 03/10=>09/10. Analyze current performance of SR-VCC solution in Rel-8 from E-UTRAN/HSPA to UTRAN/GERAN, and then evaluate additional mechanisms to improve user experience. Study if SR-VCC performance needs to be enhanced. / Text3: 23.856 / Text5: Hou zhiqiang (houzhiqiang@chinamobile.com), Jiang Yi (jiangyi@chinamobile.com)
- 63: - / Text3: 25.8xx / Text5: Heechoon Lee
- 64: Triggered by UID_7027 Study on Facilitating Machine to Machine Communication in GSM and UMTS (M2M) TR 22.868 and Rel-10 UID_410030 Network Improvements for Machine-Type Communications (NIMTC) / Text3: TR on RAN Improvements for Machine-type Communications / Text5: arnaud.meylan@huawei.com
- 65: Linked to OMA work? / Text3: 22.8xy / Text5: Li Gang (ligangyf@chinamobile.com)
